# 施工进度计划

Schedule from MS Project, 2007-06-28 to 2009-08-31.
微软中国

## Calendars

- 标准: Mon-Sun 08:00-12:00, 13:00-17:00.

## Schedule

| ID | WBS | Task | Duration | Start | Finish | Predecessors | Total slack | Free slack | Constraint |
| --- | --- | --- | --- | --- | --- | --- | --- | --- | --- |
| 1 | 1 | **施工总进度计划** | 796d | 2007-06-28 | 2009-08-31 |  | 0d |  |  |
| 2 | 1.1 | **施工准备** | 30d | 2007-06-28 | 2007-07-27 |  | 766d |  |  |
| 3 | 1.1.1 | 民工宿舍的搭建 | 10d | 2007-06-28 | 2007-07-07 |  | 766d | 0d |  |
| 4 | 1.1.2 | 现场围墙的砌筑、粉刷 | 20d | 2007-06-28 | 2007-07-17 |  | 776d |  |  |
| 5 | 1.1.3 | 项目办公楼的搭建 | 10d | 2007-07-08 | 2007-07-17 | 3 | 766d | 0d |  |
| 6 | 1.1.4 | 临时水电设备 | 30d | 2007-06-28 | 2007-07-27 |  | 766d |  |  |
| 7 | 1.1.5 | 场内道路、大门硬化 | 10d | 2007-07-18 | 2007-07-27 | 5 | 766d |  |  |
| 8 | 1.2 | **降水、护坡、土方施工** | 129d | 2007-06-28 | 2007-11-03 |  | 667d |  |  |
| 9 | 1.2.1 | 降水井成井 | 3d | 2007-06-28 | 2007-06-30 |  | 685d | 0d |  |
| 10 | 1.2.2 | 管线铺设 | 3d | 2007-07-01 | 2007-07-03 | 9 | 685d | 0d |  |
| 11 | 1.2.3 | 北侧护坡桩成桩 | 20d | 2007-07-04 | 2007-07-23 | 10 | 685d | 0d |  |
| 12 | 1.2.4 | 北侧止水帷幕桩成桩 | 10d | 2007-07-24 | 2007-08-02 | 11 | 685d | 0d |  |
| 13 | 1.2.5 | 南侧护坡桩成桩 | 15d | 2007-07-24 | 2007-08-07 |  | 714d | 0d | start no earlier than 2007-07-24 |
| 14 | 1.2.6 | F轴以南土方挖运及护坡 | 40d | 2007-08-08 | 2007-09-16 | 13 | 714d | 0d |  |
| 15 | 1.2.7 | F轴以北土方挖运及护坡 | 70d | 2007-08-03 | 2007-10-11 | 12 | 685d | 0d |  |
| 16 | 1.2.8 | 抗拔桩成桩 | 5d | 2007-10-12 | 2007-10-16 | 15 | 685d |  |  |
| 17 | 1.2.9 | 抗拔桩检测、桩头处理 | 28d | 2007-10-07 | 2007-11-03 |  | 667d |  | start no earlier than 2007-10-07 |
| 18 | 1.2.10 | 清槽、南区验槽 | 1d | 2007-09-17 | 2007-09-17 | 14 | 714d |  |  |
| 19 | 1.2.11 | 清槽、南区验槽 | 1d | 2007-10-12 | 2007-10-12 |  | 689d |  | start no earlier than 2007-10-12 |
| 20 | 1.3 | **基础结构施工** | 225d | 2007-09-29 | 2008-05-10 |  | 478d |  |  |
| 21 | 1.3.1 | II和III区垫层施工 | 2d | 2007-09-30 | 2007-10-01 |  | 700d |  | start no earlier than 2007-09-30 |
| 22 | 1.3.2 | II和III区防水及保护层施工 | 7d | 2007-11-02 | 2007-11-08 |  | 612d | 0d | start no earlier than 2007-11-02 |
| 23 | 1.3.3 | II和III区基础底板施工 | 30d | 2007-11-09 | 2007-12-08 | 22 | 612d | 0d |  |
| 24 | 1.3.4 | II和III区地下二层结构施工 | 20d | 2007-12-09 | 2007-12-28 | 23 | 612d |  |  |
| 25 | 1.3.5 | II和III区地下一层结构施工 | 21d | 2007-12-26 | 2008-01-15 |  | 594d |  | start no earlier than 2007-12-26 |
| 26 | 1.3.6 | I和IV区垫层、防水保护层施工 | 8d | 2007-09-29 | 2007-10-06 |  | 577d | 0d | start no earlier than 2007-09-29 |
| 27 | 1.3.7 | 1区基础底板施工 | 73d | 2007-10-07 | 2007-12-18 | 26 | 577d | 0d | start no earlier than 2007-10-07 |
| 28 | 1.3.8 | 1区地下二层结构施工 | 20d | 2007-12-19 | 2008-01-07 | 27 | 577d | 0d |  |
| 29 | 1.3.9 | 1区地下一层结构施工 | 25d | 2008-01-08 | 2008-02-01 | 28 | 577d |  |  |
| 30 | 1.3.10 | 4区基础底板施工 | 15d | 2008-01-17 | 2008-01-31 |  | 578d |  | finish no earlier than 2008-01-31 |
| 31 | 1.3.11 | 4区地下二层结构施工 | 40d | 2008-02-21 | 2008-03-31 | 30 | 478d | 0d | start no earlier than 2008-02-21 |
| 32 | 1.3.12 | 4区地下一层结构施工 | 40d | 2008-04-01 | 2008-05-10 | 31 | 478d |  |  |
| 33 | 1.4 | 2008年春节休息 | 20d | 2008-02-01 | 2008-02-20 |  | 337d |  | start no earlier than 2008-02-01 |

| ID | WBS | Task | Duration | Start | Finish | Predecessors | Total slack | Free slack | Constraint |
| --- | --- | --- | --- | --- | --- | --- | --- | --- | --- |
| 34 | 1.5 | **结构施工** | 290d | 2008-01-16 | 2008-10-31 |  | 304d |  |  |
| 35 | 1.5.1 | D1区结构施工 | 102d | 2008-02-25 | 2008-06-05 |  | 452d |  | start no earlier than 2008-02-25 |
| 36 | 1.5.2 | D2区结构施工 | 142d | 2008-01-16 | 2008-06-05 |  | 452d |  | start no earlier than 2008-01-16 |
| 37 | 1.5.3 | D4区结构施工 | 237d | 2008-03-09 | 2008-10-31 |  | 304d |  | finish no earlier than 2008-10-31 |
| 38 | 1.6 | 地下室至二层结构验收 | 1d | 2008-05-26 | 2008-05-26 |  | 241d |  | start no earlier than 2008-05-26 |
| 39 | 1.7 | 地上结构结构验收 | 1d | 2008-11-20 | 2008-11-20 |  | 152d | 0d | start no earlier than 2008-11-20 |
| 40 | 1.8 | 地下防水及土方回填 | 72d | 2008-09-20 | 2008-11-30 |  | 90d |  | start no earlier than 2008-09-20 |
| 41 | 1.9 | **屋面工程** | 55d | 2008-11-01 | 2008-12-25 |  | 249d |  |  |
| 42 | 1.9.1 | 屋面找坡层施工 | 10d | 2008-11-01 | 2008-11-10 |  | 284d | 0d | start no earlier than 2008-11-01 |
| 43 | 1.9.2 | 屋面找平层施工 | 10d | 2008-11-11 | 2008-11-20 | 42 | 284d |  |  |
| 44 | 1.9.3 | 屋面防水层施工 | 5d | 2008-12-01 | 2008-12-05 |  | 249d | 0d | start no earlier than 2008-12-01 |
| 45 | 1.9.4 | 屋面保温层施工 | 10d | 2008-12-06 | 2008-12-15 | 44 | 249d | 0d |  |
| 46 | 1.9.5 | 屋面面层施工 | 10d | 2008-12-16 | 2008-12-25 | 45 | 249d |  |  |
| 47 | 1.10 | **二次结构砌筑工程** | 93d | 2008-10-15 | 2009-01-15 |  | 228d |  |  |
| 48 | 1.10.1 | 地下二层砌筑 | 10d | 2008-11-20 | 2008-11-29 |  | 275d |  | start no earlier than 2008-11-20 |
| 49 | 1.10.2 | 地下一层砌筑 | 20d | 2008-11-20 | 2008-12-09 |  | 265d |  | start no earlier than 2008-11-20 |
| 50 | 1.10.3 | 首层砌筑 | 15d | 2009-01-01 | 2009-01-15 |  | 228d |  | start no earlier than 2009-01-01 |
| 51 | 1.10.4 | 2层砌筑 | 15d | 2009-01-01 | 2009-01-15 |  | 228d |  | start no earlier than 2009-01-01 |
| 52 | 1.10.5 | 3层砌筑 | 15d | 2009-01-01 | 2009-01-15 |  | 228d |  | start no earlier than 2009-01-01 |
| 53 | 1.10.6 | 4-8层砌筑 | 60d | 2008-10-15 | 2008-12-13 |  | 261d |  | start no earlier than 2008-10-15 |
| 54 | 1.11 | 2009年春节休息 | 30d | 2009-01-16 | 2009-02-14 |  | 14d |  | start no earlier than 2009-01-16 |
| 55 | 1.12 | **地下室装修施工** | 80d | 2009-02-15 | 2009-05-05 |  | 118d |  |  |
| 56 | 1.12.1 | 门窗框安装 | 20d | 2009-03-01 | 2009-03-20 |  | 164d |  | start no earlier than 2009-03-01 |
| 57 | 1.12.2 | 室抹灰 | 20d | 2009-02-15 | 2009-03-06 |  | 118d | 0d | start no earlier than 2009-02-15 |
| 58 | 1.12.3 | 刮腻子 | 20d | 2009-03-07 | 2009-03-26 | 57 | 118d | 0d |  |
| 59 | 1.12.4 | 吊顶 | 20d | 2009-03-27 | 2009-04-15 | 58 | 118d | 0d |  |
| 60 | 1.12.5 | 地面 | 20d | 2009-04-16 | 2009-05-05 | 59 | 118d |  |  |

| ID | WBS | Task | Duration | Start | Finish | Predecessors | Total slack | Free slack | Constraint |
| --- | --- | --- | --- | --- | --- | --- | --- | --- | --- |
| 61 | 1.13 | **地上装修施工** | 152d | 2009-03-01 | 2009-07-30 |  | 32d |  |  |
| 62 | 1.13.1 | 门窗框安装 | 30d | 2009-03-05 | 2009-04-03 |  | 150d |  | start no earlier than 2009-03-05 |
| 63 | 1.13.2 | 抹灰 | 50d | 2009-03-01 | 2009-04-19 |  | 134d |  | start no earlier than 2009-03-01 |
| 64 | 1.13.3 | 刮腻子 | 30d | 2009-04-05 | 2009-05-04 |  | 119d |  | start no earlier than 2009-04-05 |
| 65 | 1.13.4 | 吊顶 | 60d | 2009-05-01 | 2009-06-29 |  | 63d |  | start no earlier than 2009-05-01 |
| 66 | 1.13.5 | 地面 | 60d | 2009-06-01 | 2009-07-30 |  | 32d |  | start no earlier than 2009-06-01 |
| 67 | 1.14 | **精装修施工** | 120d | 2009-04-01 | 2009-07-29 |  | 33d |  |  |
| 68 | 1.14.1 | 墙面 | 60d | 2009-04-01 | 2009-05-30 |  | 93d |  | start no earlier than 2009-04-01 |
| 69 | 1.14.2 | 顶面 | 60d | 2009-05-01 | 2009-06-29 |  | 63d |  | start no earlier than 2009-05-01 |
| 70 | 1.14.3 | 地面 | 50d | 2009-06-01 | 2009-07-20 |  | 42d |  | start no earlier than 2009-06-01 |
| 71 | 1.14.4 | 门窗及五金 | 15d | 2009-07-15 | 2009-07-29 |  | 33d |  | start no earlier than 2009-07-15 |
| 72 | 1.15 | **室外装修** | 90d | 2009-03-01 | 2009-05-29 |  | 94d |  |  |
| 73 | 1.15.1 | 外装修施工 | 90d | 2009-03-01 | 2009-05-29 |  | 94d |  | start no earlier than 2009-03-01 |
| 74 | 1.16 | **机电工程** | 413d | 2007-11-09 | 2008-12-25 |  | 65d |  |  |
| 75 | 1.16.1 | 机电工程预留预埋 | 223d | 2007-11-09 | 2008-06-18 |  | 255d |  | start no earlier than 2007-11-09 |
| 76 | 1.16.2 | **电气工程** | 204d | 2008-06-05 | 2008-12-25 |  | 65d |  |  |
| 77 | 1.16.2.1 | 地下室电气扫管及穿线 | 36d | 2008-06-05 | 2008-07-10 |  | 69d | 0d | start no earlier than 2008-06-05 |
| 78 | 1.16.2.2 | 地下室部分电缆桥架施工 | 10d | 2008-06-15 | 2008-06-24 |  | 249d |  | start no earlier than 2008-06-15 |
| 79 | 1.16.2.3 | 地下室部分电缆施工 | 9d | 2008-06-20 | 2008-06-28 |  | 245d |  | start no earlier than 2008-06-20 |
| 80 | 1.16.2.4 | 地下室部分配电箱柜 | 15d | 2008-06-28 | 2008-07-12 |  | 231d |  | start no earlier than 2008-06-28 |
| 81 | 1.16.2.5 | 地下室部分灯具安装 | 17d | 2008-07-12 | 2008-07-28 |  | 215d |  | start no earlier than 2008-07-12 |
| 82 | 1.16.2.6 | 地上室电气扫管及穿线 | 80d | 2008-07-15 | 2008-10-02 |  | 149d |  | start no earlier than 2008-07-15 |
| 83 | 1.16.2.7 | 地上室部分电缆桥架施工 | 38d | 2008-08-05 | 2008-09-11 |  | 150d | 0d | start no earlier than 2008-08-05 |
| 84 | 1.16.2.8 | 地上室部分电缆施工 | 20d | 2008-09-12 | 2008-10-01 | 83 | 150d |  |  |
| 85 | 1.16.2.9 | 地上室部分配电箱柜 | 21d | 2008-10-01 | 2008-10-21 |  | 65d | 0d | start no earlier than 2008-10-01 |
| 86 | 1.16.2.10 | 地上室部分灯具安装 | 45d | 2008-10-22 | 2008-12-05 | 85 | 65d | 0d |  |
| 87 | 1.16.2.11 | 地下一层变配电室送电 | 40d | 2008-09-15 | 2008-10-24 |  | 127d |  | start no earlier than 2008-09-15 |
| 88 | 1.16.2.12 | 电气系统测试 | 20d | 2008-12-06 | 2008-12-25 | 86 | 65d |  |  |

| ID | WBS | Task | Duration | Start | Finish | Predecessors | Total slack | Free slack | Constraint |
| --- | --- | --- | --- | --- | --- | --- | --- | --- | --- |
| 89 | 1.16.3 | **室内给排水工程** | 200d | 2008-06-05 | 2008-12-21 |  | 69d |  |  |
| 90 | 1.16.3.1 | 给排水系统管线安装及试验 | 200d | 2008-06-05 | 2008-12-21 | 77SS | 69d |  |  |
| 91 | 1.16.3.2 | 给排水系统机房设备安装 | 60d | 2008-09-30 | 2008-11-28 |  | 92d |  | start no earlier than 2008-09-30 |
| 92 | 1.16.3.3 | 洁具安装 | 45d | 2008-10-25 | 2008-12-08 |  | 72d | 0d | start no earlier than 2008-10-25 |
| 93 | 1.16.3.4 | 给排水系统调试 | 10d | 2008-12-09 | 2008-12-18 | 92 | 72d |  |  |
| 94 | 1.16.4 | **通风空调工程** | 200d | 2008-06-05 | 2008-12-21 |  | 69d |  |  |
| 95 | 1.16.4.1 | 通风空调系统管线安装及试验 | 200d | 2008-06-05 | 2008-12-21 | 77FF | 69d |  | start no earlier than 2008-06-05 |
| 96 | 1.16.4.2 | 通风空调设备安装 | 60d | 2008-09-25 | 2008-11-23 |  | 97d |  | start no earlier than 2008-09-25 |
| 97 | 1.16.4.3 | 风口安装 | 40d | 2008-10-20 | 2008-11-28 |  | 82d | 0d | start no earlier than 2008-10-20 |
| 98 | 1.16.4.4 | 设备单机调试及系统调试 | 10d | 2008-11-29 | 2008-12-08 | 97 | 82d |  |  |
| 99 | 1.16.5 | **消防工程** | 200d | 2008-06-05 | 2008-12-21 |  | 69d |  |  |
| 100 | 1.16.5.1 | 消防给水系统管线安装及试验 | 200d | 2008-06-05 | 2008-12-21 | 77SS | 69d |  |  |
| 101 | 1.16.5.2 | 消防电气系统管线安装及测试 | 100d | 2008-06-05 | 2008-09-12 | 77SS | 89d | 0d |  |
| 102 | 1.16.5.3 | 消防给水设备及末端安装 | 60d | 2008-09-30 | 2008-11-28 |  | 92d |  | start no earlier than 2008-09-30 |
| 103 | 1.16.5.4 | 消防电气系统主机及末端设备安装 | 60d | 2008-09-13 | 2008-11-11 | 101 | 89d | 0d |  |
| 104 | 1.16.5.5 | 消防设备调试及系统调试 | 20d | 2008-11-12 | 2008-12-01 | 103 | 89d |  |  |
| 105 | 1.16.6 | **弱电工程** | 178d | 2008-06-20 | 2008-12-14 |  | 76d |  |  |
| 106 | 1.16.6.1 | 弱电系统管线安装及测试 | 100d | 2008-06-20 | 2008-09-27 |  | 109d | 0d | start no earlier than 2008-06-20 |
| 107 | 1.16.6.2 | 弱电系统主机及末端设备安装 | 65d | 2008-10-01 | 2008-12-04 | 106FS-30d | 76d | 0d | start no earlier than 2008-10-01 |
| 108 | 1.16.6.3 | 弱电系统调试 | 10d | 2008-12-05 | 2008-12-14 | 107 | 76d |  |  |
| 109 | 1.17 | **电梯工程** | 100d | 2008-11-21 | 2009-02-28 |  | 152d |  |  |
| 110 | 1.17.1 | 电梯安装 | 80d | 2008-11-21 | 2009-02-08 | 39 | 152d | 0d | start no earlier than 2008-07-15 |
| 111 | 1.17.2 | 电梯调试与验收 | 20d | 2009-02-09 | 2009-02-28 | 110 | 152d |  |  |
| 112 | 1.18 | **热力工程** | 202d | 2008-06-05 | 2008-12-23 |  | 67d |  |  |
| 113 | 1.18.1 | 换热站设备、管线安装及试验 | 150d | 2008-06-05 | 2008-11-01 |  | 119d |  | start no earlier than 2008-06-05 |
| 114 | 1.18.2 | 沟槽开挖、井室砌筑、管线施工与试验 | 40d | 2008-10-25 | 2008-12-03 |  | 67d | 0d | start no earlier than 2008-10-25 |
| 115 | 1.18.3 | 热力系统调试及验收 | 20d | 2008-12-04 | 2008-12-23 | 114 | 67d |  |  |
| 116 | 1.19 | 机电系统联动调试、验收 | 10d | 2009-08-01 | 2009-08-10 |  | 1d | 0d | start no earlier than 2009-08-01 |
| 117 | 1.20 | 竣工清理验收 | 13d | 2009-08-11 | 2009-08-23 | 116 | 1d | 0d |  |
| 118 | 1.21 | 竣工预验收及清理 | 7d | 2009-08-24 | 2009-08-30 | 117 | 1d |  | start no earlier than 2009-08-23 |
| 119 | 1.22 | 竣工验收 | 1d | 2009-08-31 | 2009-08-31 |  | 0d |  | start no earlier than 2009-08-31 |
